# 20190612 Planning rwzi Nieuwveen DO-Oplevering

Schedule from MS Project, 2021-10-27 to 2023-09-06.
Royal Haskoning

## Calendars

- Standard: Mon-Fri 08:00-12:00, 13:00-17:00; Sat-Sun off. Exceptions (off unless hours are given): 2021-12-27 to 2022-01-07 (kerstvakantie 2021), 2022-08-01 to 2022-08-19 (zomervakantie 2022), 2022-12-24 to 2023-01-01 (kerstvakantie 2022), 2023-07-31 to 2023-08-18 (Zomervakantie 2023).
- werkdagen: Mon-Fri 08:00-12:00, 13:00-17:00; Sat-Sun 09:00-12:00, 13:00-17:00.

## Schedule

| ID | WBS | Task | Type | Duration | Start | Finish | Predecessors | Total slack | Free slack | Calendar |
| --- | --- | --- | --- | --- | --- | --- | --- | --- | --- | --- |
| 1 | 1 | **Activiteiten HHR** |  | 114d | 2021-10-27 | 2022-04-18 |  | 30d |  |  |
| 2 | 1.1 | **Aanbesteding en gunningsfase AKZ** |  | 114d | 2021-10-27 | 2022-04-18 |  | 30d |  |  |
| 3 | 1.1.1 | Voorbereiding aanbesteding |  | 30d | 2021-10-27 | 2021-12-08 | 4SF | 395d |  |  |
| 4 | 1.1.2 | Contractstukken opsturen naar aannemers | manual | 1d | 2021-12-08 | 2021-12-08 |  |  |  |  |
| 5 | 1.1.3 | Rekentijd aannemers + NVI (kalenderdagen) |  | 88ed | 2021-12-08 | 2022-03-06 | 4 | 1.88d |  | werkdagen |
| 6 | 1.1.4 | Indienen aanbestedingsdocumenten aannemers |  | 1d | 2022-03-07 | 2022-03-07 | 5 | 0d |  |  |
| 7 | 1.1.5 | Beoordeling en voorlopige gunning |  | 15d | 2022-03-08 | 2022-03-28 | 6 | 0d |  |  |
| 8 | 1.1.6 | Alcatel periode (kalenderdagen) |  | 21ed | 2022-03-28 | 2022-04-18 | 7 | 1.88d | 0d | werkdagen |
| 9 | 1.1.7 | Definitieve gunning | milestone | 0d | 2022-04-18 | 2022-04-18 | 8 | 0d |  |  |
| 10 | 2 | **UITVOERINGSFASE ZK ALPHEN KERK EN ZANEN** |  | 322d | 2022-04-25 | 2023-09-06 |  | 0d |  |  |
| 11 | 2.1 | Datum aanvang | milestone | 0d | 2022-04-25 | 2022-04-25 | 9FS+5d | 0d |  |  |
| 12 | 2.2 | Engineering aannemer |  | 60d | 2022-04-26 | 2022-07-18 | 9, 11 | 0d |  |  |
| 13 | 2.3 | Engineerin aannemer gereed [UM] | milestone | 0d | 2022-07-18 | 2022-07-18 | 12 | 262d |  |  |
| 14 | 2.4 | Bestellen/reserveren long lead items (Ontwateringsmachine, silo, roosters, blowers) |  | 6mo | 2022-06-21 | 2023-01-02 | 12FS-20d | 31d | 4d |  |
| 15 | 2.5 | Bestellen en inkoop mengers en equipement selector en contactruimte |  | 40d | 2022-07-05 | 2022-09-19 | 12FS-10d | 0d |  |  |
| 16 | 2.6 | Bestellen en produceren skids plaatbeluchting |  | 60d | 2022-07-19 | 2022-10-31 | 12 | 53d | 15d |  |
| 17 | 2.7 | Bestellen en inkoop overige items |  | 80d | 2022-07-19 | 2022-11-28 | 12 | 46d | 0d |  |
| 18 | 2.8 | **Werkzaamheden awzi Alphen Kerk en Zanen** |  | 147d | 2022-09-20 | 2023-04-19 |  | 0d |  |  |
| 19 | 2.8.1 | Mobilisatie |  | 2w | 2022-09-20 | 2022-10-03 | 12, 15 | 0d |  |  |
| 20 | 2.8.2 | **Fase 1 - Contactruimte en anaerobe ruimte** |  | 20d | 2022-10-04 | 2022-10-31 |  | 38d |  |  |
| 21 | 2.8.2.1 | Reinigen contactruimte en anaerobe ruimte |  | 5d | 2022-10-04 | 2022-10-10 | 19, 15FS-5d | 38d | 0d |  |
| 22 | 2.8.2.2 | Repareren beton en lining |  | 2w | 2022-10-11 | 2022-10-24 | 21 | 38d | 0d |  |
| 23 | 2.8.2.3 | Monteren en aansluiten mengers |  | 2w | 2022-10-11 | 2022-10-24 | 21, 15 | 38d | 0d |  |
| 24 | 2.8.2.4 | SAT en IBS |  | 5d | 2022-10-25 | 2022-10-31 | 22, 23 | 38d | 0d |  |

| ID | WBS | Task | Type | Duration | Start | Finish | Predecessors | Total slack | Free slack | Constraint |
| --- | --- | --- | --- | --- | --- | --- | --- | --- | --- | --- |
| 25 | 2.8.3 | **Fase 2 - Aanpassen Beluchtingstank 1** |  | 25d | 2022-11-01 | 2022-12-05 |  | 38d |  |  |
| 26 | 2.8.3.1 | Inblokken, leegpompen en reinigen |  | 1w | 2022-11-01 | 2022-11-07 | 24 | 38d | 0d |  |
| 27 | 2.8.3.2 | Aanpassen luchtleidingen |  | 2w | 2022-11-08 | 2022-11-21 | 26 | 38d | 0d |  |
| 28 | 2.8.3.3 | Verwijderen schotels en betonreparaties |  | 2w | 2022-11-08 | 2022-11-21 | 26 | 38d | 0d |  |
| 29 | 2.8.3.4 | Inhijsen skids plaatbeluchting en aansluiten |  | 1w | 2022-11-22 | 2022-11-28 | 28, 27, 16 | 38d | 0d |  |
| 30 | 2.8.3.5 | Vullen en in bedrijf stellen |  | 1w | 2022-11-29 | 2022-12-05 | 29 | 38d | 0d |  |
| 31 | 2.8.4 | **Fase 3 - Aanpassen Beluchtingstank 2** |  | 25d | 2022-12-06 | 2023-01-16 |  | 38d |  |  |
| 32 | 2.8.4.1 | Inblokken, leegpompen en reinigen |  | 1w | 2022-12-06 | 2022-12-12 | 24, 30 | 38d | 0d |  |
| 33 | 2.8.4.2 | Aanpassen luchtleidingen |  | 2w | 2022-12-13 | 2023-01-02 | 32 | 38d | 0d |  |
| 34 | 2.8.4.3 | Verwijderen schotels en betonreparaties |  | 2w | 2022-12-13 | 2023-01-02 | 32 | 38d | 0d |  |
| 35 | 2.8.4.4 | Inhijsen skids plaatbeluchting en aansluiten |  | 1w | 2023-01-03 | 2023-01-09 | 33, 34, 16 | 38d | 0d |  |
| 36 | 2.8.4.5 | Vullen en in bedrijf stellen |  | 1w | 2023-01-10 | 2023-01-16 | 35 | 38d | 0d |  |
| 37 | 2.8.5 | **Fase 4** |  | 15d | 2023-01-17 | 2023-02-06 |  | 38d |  |  |
| 38 | 2.8.5.1 | Plaatsen TPI slibretour (1200 m3/uur) |  | 5d | 2023-01-17 | 2023-01-23 | 36 | 38d | 0d |  |
| 39 | 2.8.5.2 | Aanpassen Nabezinktank 2 |  | 2w | 2023-01-24 | 2023-02-06 | 36FS+5d, 38 | 38d | 0d |  |
| 40 | 2.8.6 | **Fase 5** |  | 16d | 2023-02-07 | 2023-02-28 |  | 38d |  |  |
| 41 | 2.8.6.1 | Plaatsen TPI gedeeltelijke bypass 700 mm leiding |  | 4d | 2023-02-07 | 2023-02-10 | 39 | 38d | 0d |  |
| 42 | 2.8.6.2 | Aanpassen Nabezinktank 1 |  | 2w | 2023-02-13 | 2023-02-24 | 39, 41 | 38d | 0d |  |
| 43 | 2.8.6.3 | Ombouw tanks gereed [UM] | milestone | 0d | 2023-02-24 | 2023-02-24 | 42 | 123d |  |  |
| 44 | 2.8.6.4 | Verwijderen TPI's slibretour en bypass verwijderen |  | 2d | 2023-02-27 | 2023-02-28 | 42 | 121d |  |  |
| 45 | 2.8.7 | **Overige aanpassingen:** |  | 147d | 2022-09-20 | 2023-04-19 |  | 0d |  |  |
| 46 | 2.8.7.1 | Rooien begroeiing (Romneyloods, zonneweide en biodiversiteit) na bouwvak ivm broedseizoen |  | 2w | 2022-09-20 | 2022-10-03 | 19FS-10d | 0d |  | start no earlier than 2022-08-29 |
| 47 | 2.8.7.2 | Verplaatsen Romneyloods |  | 2w | 2022-09-27 | 2022-10-10 | 46FS-5d | 0d |  |  |
| 48 | 2.8.7.3 | Opstellen en aansluiten tijdelijke slibverlading en tijdelijk geurfilter waterlijn |  | 2w | 2022-09-20 | 2022-10-03 | 46SS | 5d |  |  |
| 49 | 2.8.7.4 | Slopen slibverlading en geurfilters en overig voorbereiden grondwerk voor Terreinrioolput, E&I gebouw en 2e influentgoot |  | 2w | 2022-10-11 | 2022-10-24 | 48, 47 | 0d |  |  |
| 50 | 2.8.7.5 | Schroefpalen voor diverse objecten aanbrengen |  | 2w | 2022-10-25 | 2022-11-07 | 49 | 0d |  |  |

| ID | WBS | Task | Duration | Start | Finish | Predecessors | Total slack | Free slack |
| --- | --- | --- | --- | --- | --- | --- | --- | --- |
| 51 | 2.8.7.6 | **Funderingen** | 34d | 2022-11-01 | 2022-12-18 |  | 0d |  |
| 52 | 2.8.7.6.1 | Fundering E&I gebouw | 5d | 2022-11-01 | 2022-11-07 | 50FS-5d | 0d |  |
| 53 | 2.8.7.6.2 | Uitharden fundering E&I gebouw | 20ed | 2022-11-07 | 2022-11-27 | 52 | 133.88d | 1.88d |
| 54 | 2.8.7.6.3 | Overige funderingen | 15d | 2022-11-08 | 2022-11-28 | 52 | 0d |  |
| 55 | 2.8.7.6.4 | Uitharden funderingen | 20ed | 2022-11-28 | 2022-12-18 | 54 | 1.88d |  |
| 56 | 2.8.7.7 | **Geurfilters waterlijn** | 25d | 2022-12-19 | 2023-01-27 |  | 58d |  |
| 57 | 2.8.7.7.1 | Plaatsen en aansluiten nieuwe geurfilters waterlijn | 25d | 2022-12-19 | 2023-01-27 | 55, 17 | 58d |  |
| 58 | 2.8.7.8 | **E&I gebouw** | 64d | 2022-10-11 | 2023-01-13 |  | 61d |  |
| 59 | 2.8.7.8.1 | Trekputten en mantelbuizen aanbrengen | 4w | 2022-10-11 | 2022-11-07 | 47 | 197d |  |
| 60 | 2.8.7.8.2 | E&I gebouw bouwen | 20d | 2022-11-28 | 2022-12-23 | 53 | 27d | 0d |
| 61 | 2.8.7.8.3 | Verdelers en kasten plaatsen en aansluiten op trafo | 2w | 2023-01-02 | 2023-01-13 | 60, 17 | 27d | 0d |
| 62 | 2.8.7.9 | **Slibontwatering** | 45d | 2023-01-09 | 2023-03-10 |  | 33d |  |
| 63 | 2.8.7.9.1 | Plaatsen tijdelijke slibonwateringsvoorziening | 5d | 2023-01-09 | 2023-01-16 | 64SF | 153d |  |
| 64 | 2.8.7.9.2 | Verwijderen slibontwateringsmachine | 5d | 2023-01-16 | 2023-01-20 | 52FF, 61 | 28d | 0d |
| 65 | 2.8.7.9.3 | Plaatsen Nieuwe slibontwateringsmachine | 5d | 2023-01-16 | 2023-01-20 | 64FS-5d, 14 | 28d | 0d |
| 66 | 2.8.7.9.4 | Plaatsen slibsilo | 5d | 2023-01-16 | 2023-01-20 | 65SS, 14, 55 | 148d |  |
| 67 | 2.8.7.9.5 | Afmonteren ontwateringsinstallaties en slibsilo W+E | 4w | 2023-01-23 | 2023-02-17 | 65 | 28d | 0d |
| 68 | 2.8.7.9.6 | SAT Slibontwatering en storingsvrije periode | 2w | 2023-02-20 | 2023-03-03 | 67 | 28d | 0d |
| 69 | 2.8.7.9.7 | Verwijderen tijdelijke slibontwatering en verlading | 1w | 2023-03-06 | 2023-03-10 | 68 | 28d |  |
| 70 | 2.8.7.10 | **Blowers** | 46d | 2023-01-09 | 2023-03-13 |  | 27d |  |
| 71 | 2.8.7.10.1 | Plaatsen aansluiten en testen nieuwe blower 4 | 3w | 2023-01-09 | 2023-01-27 | 61FS-5d, 14 | 27d | 0d |
| 72 | 2.8.7.10.2 | Vervangen blower 1 | 2w | 2023-01-31 | 2023-02-13 | 14, 71FS+1d | 27d | 0d |
| 73 | 2.8.7.10.3 | Vervangen blower 2 | 2w | 2023-02-14 | 2023-02-27 | 72 | 27d | 0d |
| 74 | 2.8.7.10.4 | Vervangen blower 3 | 2w | 2023-02-28 | 2023-03-13 | 73 | 27d |  |

| ID | WBS | Task | Duration | Start | Finish | Predecessors | Total slack | Free slack |
| --- | --- | --- | --- | --- | --- | --- | --- | --- |
| 75 | 2.8.7.11 | **Roostergoed** | 83d | 2022-12-19 | 2023-04-19 |  | 0d |  |
| 76 | 2.8.7.11.1 | Bouwen 2e influentgoot en roostergoedgoot | 9w | 2022-12-19 | 2023-02-24 | 50, 55 | 0d |  |
| 77 | 2.8.7.11.2 | Opstellen en aansluiten tijdelijke roostergoedinstallatie | 2w | 2023-02-27 | 2023-03-10 | 61, 76 | 0d |  |
| 78 | 2.8.7.11.3 | Schuiven, Roostergoedinstallaties aanbrengen, zandvang reinigen en repareren | 20d | 2023-03-13 | 2023-04-07 | 77, 61, 14 | 0d |  |
| 79 | 2.8.7.11.4 | Testen en IBS | 5d | 2023-04-10 | 2023-04-14 | 78 | 0d |  |
| 80 | 2.8.7.11.5 | Verwijderen tijdelijk roostergoedinstallatie | 3d | 2023-04-17 | 2023-04-19 | 79 | 0d |  |
| 81 | 2.8.7.12 | **Terreinriolering en bedrijfswater** | 15d | 2022-11-29 | 2022-12-19 |  | 82d |  |
| 82 | 2.8.7.12.1 | Plaatsen prefab terreinrioolput | 5d | 2022-11-29 | 2022-12-05 | 50FS+10d, 17 | 82d | 0d |
| 83 | 2.8.7.12.2 | Inrichten en aansluiten terreinriolering en afvoer | 10d | 2022-12-06 | 2022-12-19 | 82 | 82d |  |
| 84 | 2.8.7.13 | **Retourslibgemaal** | 35d | 2023-01-09 | 2023-02-24 |  | 43d |  |
| 85 | 2.8.7.13.1 | Plaatsen TPI voor retourslib | 5d | 2023-01-09 | 2023-01-13 | 86SS-5d | 153d |  |
| 86 | 2.8.7.13.2 | Slopen installaties | 1w | 2023-01-16 | 2023-01-20 | 61 | 38d | 0d |
| 87 | 2.8.7.13.3 | Betonreparaties | 1w | 2023-01-23 | 2023-01-27 | 86 | 38d | 0d |
| 88 | 2.8.7.13.4 | Monteren nieuwe gemalen | 2w | 2023-01-30 | 2023-02-10 | 87, 17 | 38d | 0d |
| 89 | 2.8.7.13.5 | Indraaien en SAT | 5d | 2023-02-13 | 2023-02-17 | 88 | 38d | 0d |
| 90 | 2.8.7.13.6 | Verwijderen tijdelijke retourslibinstallatie | 5d | 2023-02-20 | 2023-02-24 | 89 | 38d |  |
| 91 | 2.9 | Afronden en ISAT | 4w | 2023-04-20 | 2023-05-17 | 42, 90, 83, 80, 74, 69, 57 | 0d |  |
| 92 | 2.10 | **AWTG's** | 216d | 2022-04-26 | 2023-03-21 |  | 41d |  |
| 93 | 2.10.1 | **Werkzaamheden AWTG Alphen West** | 151d | 2022-04-26 | 2022-12-13 |  | 41d |  |
| 94 | 2.10.1.1 | Engineering C/W/E onderdelen lange levertijd | 40d | 2022-04-26 | 2022-06-20 | 11 | 41d | 0d |
| 95 | 2.10.1.2 | Bestellen C/W/E onderdelen lange levertijd | 80d | 2022-06-07 | 2022-10-17 | 94FS-10d | 212d | 0d |
| 96 | 2.10.1.3 | Werkplan TPI | 5d | 2022-05-10 | 2022-05-16 | 94SS+10d | 41d | 0d |
| 97 | 2.10.1.4 | Engineering gereed | 1d | 2022-06-21 | 2022-06-21 | 94 | 281d |  |
| 98 | 2.10.1.5 | Levertijd pompen + FAT | 80d | 2022-06-07 | 2022-10-17 | 95SS | 212d |  |
| 99 | 2.10.1.6 | Levertijd TPI | 70d | 2022-05-17 | 2022-09-12 | 96 | 41d | 0d |
| 100 | 2.10.1.7 | Levertijd schakelkast + FAT | 30d | 2022-06-07 | 2022-07-18 | 95SS | 262d |  |
| 101 | 2.10.1.8 | Plaatsen TPI | 5d | 2022-09-13 | 2022-09-19 | 99 | 41d | 0d |
| 102 | 2.10.1.9 | Proefdraaien TPI | 5d | 2022-09-20 | 2022-09-26 | 101 | 41d | 0d |
| 103 | 2.10.1.10 | Bedrijfsperiode TPI | 55d | 2022-09-27 | 2022-12-12 | 102 | 41d | 0d |
| 104 | 2.10.1.11 | Amoveren bestaande installaties C/W/E | 10d | 2022-09-27 | 2022-10-10 | 103SS | 106d | 0d |
| 105 | 2.10.1.12 | Civiele werkzaamheden | 10d | 2022-10-11 | 2022-10-24 | 104 | 121d | 15d |
| 106 | 2.10.1.13 | Werktuigbouwkundige werkzaamheden | 15d | 2022-10-11 | 2022-10-31 | 104 | 116d | 10d |
| 107 | 2.10.1.14 | Elektrotechnische werkzaamheden | 25d | 2022-10-11 | 2022-11-14 | 104 | 106d | 0d |
| 108 | 2.10.1.15 | Montage eind inspectie (WTB/ E) | 1d | 2022-11-15 | 2022-11-15 | 105, 106, 107 | 106d | 0d |
| 109 | 2.10.1.16 | I/O testen | 5d | 2022-11-16 | 2022-11-22 | 108 | 106d | 0d |
| 110 | 2.10.1.17 | PA Sotware implementeren | 1d | 2022-11-23 | 2022-11-23 | 109 | 106d | 0d |
| 111 | 2.10.1.18 | SAT capaciteitstest 1 | 2d | 2022-11-24 | 2022-11-25 | 110 | 106d | 0d |
| 112 | 2.10.1.19 | Inbedrijfname AWTG | 1d | 2022-11-28 | 2022-11-28 | 111 | 106d | 0d |
| 113 | 2.10.1.20 | 14 dagen test (storingsvrije periode) | 14ed | 2022-11-28 | 2022-12-12 | 112 | 466.88d | 1.88d |
| 114 | 2.10.1.21 | Restpunten/ Terreinafwerking | 5d | 2022-11-29 | 2022-12-05 | 112 | 111d | 0d |
| 115 | 2.10.1.22 | Opleverdossier | 80d | 2022-07-19 | 2022-11-29 | 94SS, 114SF | 116d | 10d |
| 116 | 2.10.1.23 | Vervroegde ingebruikneming AWTG | 1d | 2022-12-13 | 2022-12-13 | 113, 114, 115 | 106d |  |

| ID | WBS | Task | Duration | Start | Finish | Predecessors | Total slack | Free slack |
| --- | --- | --- | --- | --- | --- | --- | --- | --- |
| 117 | 2.10.2 | **Werkzaamheden AWTG Alphen Kerk en Zanen** | 201d | 2022-05-17 | 2023-03-21 |  | 91d |  |
| 118 | 2.10.2.1 | Engineering C/W/E onderdelen lange levertijd | 40d | 2022-05-17 | 2022-07-11 | 94SS+15d | 91d | 0d |
| 119 | 2.10.2.2 | Bestellen C/W/E onderdelen lange levertijd | 80d | 2022-06-28 | 2022-11-07 | 118FS-10d | 101d | 0d |
| 120 | 2.10.2.3 | Werkplan TPI | 5d | 2022-05-31 | 2022-06-06 | 118SS+10d | 91d | 0d |
| 121 | 2.10.2.4 | Engineering gereed | 1d | 2022-07-12 | 2022-07-12 | 118 | 266d |  |
| 122 | 2.10.2.5 | Levertijd pompen + FAT | 80d | 2022-06-28 | 2022-11-07 | 119SS | 197d |  |
| 123 | 2.10.2.6 | Levertijd TPI | 70d | 2022-06-07 | 2022-10-03 | 120 | 91d | 50d |
| 124 | 2.10.2.7 | Levertijd schakelkast + FAT | 30d | 2022-06-28 | 2022-08-29 | 119SS | 247d |  |
| 125 | 2.10.2.8 | Plaatsen TPI | 5d | 2022-12-13 | 2022-12-19 | 123, 103 | 41d | 0d |
| 126 | 2.10.2.9 | Proefdraaien TPI | 5d | 2022-12-20 | 2023-01-02 | 125 | 41d | 0d |
| 127 | 2.10.2.10 | Bedrijfsperiode TPI | 55d | 2023-01-03 | 2023-03-20 | 126 | 41d | 0d |
| 128 | 2.10.2.11 | Amoveren bestaande installaties C/W/E | 10d | 2023-01-03 | 2023-01-16 | 127SS | 41d | 0d |
| 129 | 2.10.2.12 | Civiele werkzaamheden | 25d | 2023-01-17 | 2023-02-20 | 128 | 41d | 0d |
| 130 | 2.10.2.13 | Werktuigbouwkundige werkzaamheden | 10d | 2023-01-17 | 2023-01-30 | 128 | 56d | 15d |
| 131 | 2.10.2.14 | Elektrotechnische werkzaamheden | 25d | 2023-01-17 | 2023-02-20 | 128 | 41d | 0d |
| 132 | 2.10.2.15 | Montage eind inspectie (WTB/ E) | 1d | 2023-02-21 | 2023-02-21 | 129, 130, 131, 142 | 41d | 0d |
| 133 | 2.10.2.16 | I/O testen | 5d | 2023-02-22 | 2023-02-28 | 132 | 41d | 0d |
| 134 | 2.10.2.17 | PA Sotware implementeren | 1d | 2023-03-01 | 2023-03-01 | 133 | 41d | 0d |
| 135 | 2.10.2.18 | SAT capaciteitstest 1 | 2d | 2023-03-02 | 2023-03-03 | 134 | 41d | 0d |
| 136 | 2.10.2.19 | Inbedrijfname AWTG | 1d | 2023-03-06 | 2023-03-06 | 135 | 41d | 0d |
| 137 | 2.10.2.20 | 14 dagen test (storingsvrije periode) | 14ed | 2023-03-06 | 2023-03-20 | 136 | 172.88d | 1.88d |
| 138 | 2.10.2.21 | Restpunten/ Terreinafwerking | 5d | 2023-03-07 | 2023-03-13 | 136 | 46d | 0d |
| 139 | 2.10.2.22 | Opleverdossier | 80d | 2022-11-08 | 2023-03-07 | 118SS, 138SF | 51d | 10d |
| 140 | 2.10.2.23 | Vervroegde ingebruikneming AWTG | 1d | 2023-03-21 | 2023-03-21 | 137, 138, 139 | 41d |  |

| ID | WBS | Task | Type | Duration | Start | Finish | Predecessors | Total slack | Free slack |
| --- | --- | --- | --- | --- | --- | --- | --- | --- | --- |
| 141 | 2.10.3 | **Werkzaamheden AWTG Hazerwoude Rijndijk** |  | 16d | 2022-10-31 | 2022-11-22 |  | 106.5d |  |
| 142 | 2.10.3.1 | Civiele werkzaamheden |  | 10d | 2022-11-08 | 2022-11-21 | 119 | 101d | 60d |
| 143 | 2.10.3.2 | Monteren en aansluiten meting |  | 2d | 2022-11-08 | 2022-11-09 | 119 | 186.5d | 0d |
| 144 | 2.10.3.3 | Montage eind inspectie (WTB/ E) |  | 1d | 2022-11-10 | 2022-11-10 | 143 | 186.5d | 0d |
| 145 | 2.10.3.4 | I/O testen |  | 0.5d | 2022-11-11 | 2022-11-11 | 144 | 186.5d | 0d |
| 146 | 2.10.3.5 | PA Sotware implementeren |  | 0.5d | 2022-11-11 | 2022-11-11 | 145 | 186.5d | 0d |
| 147 | 2.10.3.6 | SAT capaciteitstest 1 |  | 0.5d | 2022-11-14 | 2022-11-14 | 146 | 186.5d | 0d |
| 148 | 2.10.3.7 | Inbedrijfname AWTG | milestone | 0d | 2022-11-14 | 2022-11-14 | 147 | 186.5d | 0d |
| 149 | 2.10.3.8 | Restpunten/ Terreinafwerking |  | 5d | 2022-11-14 | 2022-11-21 | 148 | 186.5d | 0d |
| 150 | 2.10.3.9 | Opleverdossier |  | 10d | 2022-10-31 | 2022-11-14 | 149SF | 191.5d | 5d |
| 151 | 2.10.3.10 | Vervroegde ingebruikneming AWTG (MIJLPAAL) |  | 1d | 2022-11-21 | 2022-11-22 | 149, 150 | 186.5d |  |
| 152 | 2.11 | Oplevering (MIJLPAAL) | milestone | 0d | 2023-05-17 | 2023-05-17 | 91, 140, 116 | 0d |  |
| 153 | 2.12 | Restpunten en nazorg |  | 13w | 2023-05-18 | 2023-09-06 | 152 | 0d |  |
