# 20190612 Planning rwzi Nieuwveen DO-Oplevering

Schedule from MS Project, 2021-10-27 to 2024-04-10.
Royal Haskoning

## Calendars

- Standard: Mon-Fri 08:00-12:00, 13:00-17:00; Sat-Sun off. Exceptions (off unless hours are given): 2021-12-27 to 2022-01-07 (kerstvakantie 2021), 2022-08-01 to 2022-08-19 (zomervakantie 2022), 2022-12-24 to 2023-01-01 (kerstvakantie 2022), 2023-07-31 to 2023-08-18 (Zomervakantie 2023), 2023-12-25 to 2024-01-05 (Kerstvakantie 2023).
- werkdagen: Mon-Fri 08:00-12:00, 13:00-17:00; Sat-Sun 09:00-12:00, 13:00-17:00.

## Schedule

| ID | WBS | Task | Type | Duration | Start | Finish | Predecessors | Total slack | Free slack | Calendar |
| --- | --- | --- | --- | --- | --- | --- | --- | --- | --- | --- |
| 1 | 1 | **Activiteiten HHR** |  | 114d | 2021-10-27 | 2022-04-18 |  | 30d |  |  |
| 2 | 1.1 | **Aanbesteding en gunningsfase AKZ** |  | 114d | 2021-10-27 | 2022-04-18 |  | 30d |  |  |
| 3 | 1.1.1 | Voorbereiding aanbesteding |  | 30d | 2021-10-27 | 2021-12-08 | 4SF | 531d |  |  |
| 4 | 1.1.2 | Contractstukken opsturen naar aannemers | manual | 1d | 2021-12-08 | 2021-12-08 |  |  |  |  |
| 5 | 1.1.3 | Rekentijd aannemers + NVI (kalenderdagen) |  | 88ed | 2021-12-08 | 2022-03-06 | 4 | 1.88d |  | werkdagen |
| 6 | 1.1.4 | Indienen aanbestedingsdocumenten aannemers |  | 1d | 2022-03-07 | 2022-03-07 | 5 | 0d |  |  |
| 7 | 1.1.5 | Beoordeling en voorlopige gunning |  | 15d | 2022-03-08 | 2022-03-28 | 6 | 0d |  |  |
| 8 | 1.1.6 | Alcatel periode (kalenderdagen) |  | 21ed | 2022-03-28 | 2022-04-18 | 7 | 1.88d | 0d | werkdagen |
| 9 | 1.1.7 | Definitieve gunning | milestone | 0d | 2022-04-18 | 2022-04-18 | 8 | 0d |  |  |
| 10 | 2 | **UITVOERINGSFASE ZK ALPHEN KERK EN ZANEN** |  | 467d | 2022-04-25 | 2024-04-10 |  | 0d |  |  |
| 11 | 2.1 | Datum aanvang | milestone | 0d | 2022-04-25 | 2022-04-25 | 9FS+5d | 145d | 0d |  |
| 12 | 2.2 | Engineering aannemer |  | 60d | 2022-04-26 | 2022-07-18 | 9, 11 | 145d | 0d |  |
| 13 | 2.3 | Engineerin aannemer gereed [UM] | milestone | 0d | 2022-07-18 | 2022-07-18 | 12 | 407d |  |  |
| 14 | 2.4 | Bestellen/reserveren long lead items (Ontwateringsmachine, silo, roosters, blowers) |  | 6mo | 2022-06-21 | 2023-01-02 | 12FS-20d | 176d | 4d |  |
| 15 | 2.5 | Bestellen en inkoop mengers en equipement selector en contactruimte |  | 40d | 2022-07-05 | 2022-09-19 | 12FS-10d | 145d | 0d |  |
| 16 | 2.6 | Bestellen en produceren skids plaatbeluchting |  | 60d | 2022-07-19 | 2022-10-31 | 12 | 198d | 15d |  |
| 17 | 2.7 | Bestellen en inkoop overige items |  | 80d | 2022-07-19 | 2022-11-28 | 12 | 191d | 0d |  |
| 18 | 2.8 | **Werkzaamheden awzi Alphen Kerk en Zanen** |  | 147d | 2022-09-20 | 2023-04-19 |  | 145d |  |  |
| 19 | 2.8.1 | Mobilisatie |  | 2w | 2022-09-20 | 2022-10-03 | 12, 15 | 145d | 0d |  |
| 20 | 2.8.2 | **Fase 1 - Contactruimte en anaerobe ruimte** |  | 20d | 2022-10-04 | 2022-10-31 |  | 183d |  |  |
| 21 | 2.8.2.1 | Reinigen contactruimte en anaerobe ruimte |  | 5d | 2022-10-04 | 2022-10-10 | 19, 15FS-5d | 183d | 0d |  |
| 22 | 2.8.2.2 | Repareren beton en lining |  | 2w | 2022-10-11 | 2022-10-24 | 21 | 183d | 0d |  |
| 23 | 2.8.2.3 | Monteren en aansluiten mengers |  | 2w | 2022-10-11 | 2022-10-24 | 21, 15 | 183d | 0d |  |
| 24 | 2.8.2.4 | SAT en IBS |  | 5d | 2022-10-25 | 2022-10-31 | 22, 23 | 183d | 0d |  |

| ID | WBS | Task | Type | Duration | Start | Finish | Predecessors | Total slack | Free slack | Constraint |
| --- | --- | --- | --- | --- | --- | --- | --- | --- | --- | --- |
| 25 | 2.8.3 | **Fase 2 - Aanpassen Beluchtingstank 1** |  | 25d | 2022-11-01 | 2022-12-05 |  | 183d |  |  |
| 26 | 2.8.3.1 | Inblokken, leegpompen en reinigen |  | 1w | 2022-11-01 | 2022-11-07 | 24 | 183d | 0d |  |
| 27 | 2.8.3.2 | Aanpassen luchtleidingen |  | 2w | 2022-11-08 | 2022-11-21 | 26 | 183d | 0d |  |
| 28 | 2.8.3.3 | Verwijderen schotels en betonreparaties |  | 2w | 2022-11-08 | 2022-11-21 | 26 | 183d | 0d |  |
| 29 | 2.8.3.4 | Inhijsen skids plaatbeluchting en aansluiten |  | 1w | 2022-11-22 | 2022-11-28 | 28, 27, 16 | 183d | 0d |  |
| 30 | 2.8.3.5 | Vullen en in bedrijf stellen |  | 1w | 2022-11-29 | 2022-12-05 | 29 | 183d | 0d |  |
| 31 | 2.8.4 | **Fase 3 - Aanpassen Beluchtingstank 2** |  | 25d | 2022-12-06 | 2023-01-16 |  | 183d |  |  |
| 32 | 2.8.4.1 | Inblokken, leegpompen en reinigen |  | 1w | 2022-12-06 | 2022-12-12 | 24, 30 | 183d | 0d |  |
| 33 | 2.8.4.2 | Aanpassen luchtleidingen |  | 2w | 2022-12-13 | 2023-01-02 | 32 | 183d | 0d |  |
| 34 | 2.8.4.3 | Verwijderen schotels en betonreparaties |  | 2w | 2022-12-13 | 2023-01-02 | 32 | 183d | 0d |  |
| 35 | 2.8.4.4 | Inhijsen skids plaatbeluchting en aansluiten |  | 1w | 2023-01-03 | 2023-01-09 | 33, 34, 16 | 183d | 0d |  |
| 36 | 2.8.4.5 | Vullen en in bedrijf stellen |  | 1w | 2023-01-10 | 2023-01-16 | 35 | 183d | 0d |  |
| 37 | 2.8.5 | **Fase 4** |  | 15d | 2023-01-17 | 2023-02-06 |  | 183d |  |  |
| 38 | 2.8.5.1 | Plaatsen TPI slibretour (1200 m3/uur) |  | 5d | 2023-01-17 | 2023-01-23 | 36 | 183d | 0d |  |
| 39 | 2.8.5.2 | Aanpassen Nabezinktank 2 |  | 2w | 2023-01-24 | 2023-02-06 | 36FS+5d, 38 | 183d | 0d |  |
| 40 | 2.8.6 | **Fase 5** |  | 16d | 2023-02-07 | 2023-02-28 |  | 183d |  |  |
| 41 | 2.8.6.1 | Plaatsen TPI gedeeltelijke bypass 700 mm leiding |  | 4d | 2023-02-07 | 2023-02-10 | 39 | 183d | 0d |  |
| 42 | 2.8.6.2 | Aanpassen Nabezinktank 1 |  | 2w | 2023-02-13 | 2023-02-24 | 39, 41 | 183d | 0d |  |
| 43 | 2.8.6.3 | Ombouw tanks gereed [UM] | milestone | 0d | 2023-02-24 | 2023-02-24 | 42 | 268d |  |  |
| 44 | 2.8.6.4 | Verwijderen TPI's slibretour en bypass verwijderen |  | 2d | 2023-02-27 | 2023-02-28 | 42 | 266d |  |  |
| 45 | 2.8.7 | **Overige aanpassingen:** |  | 147d | 2022-09-20 | 2023-04-19 |  | 145d |  |  |
| 46 | 2.8.7.1 | Rooien begroeiing (Romneyloods, zonneweide en biodiversiteit) na bouwvak ivm broedseizoen |  | 2w | 2022-09-20 | 2022-10-03 | 19FS-10d | 145d | 0d | start no earlier than 2022-08-29 |
| 47 | 2.8.7.2 | Verplaatsen Romneyloods |  | 2w | 2022-09-27 | 2022-10-10 | 46FS-5d | 145d | 0d |  |
| 48 | 2.8.7.3 | Opstellen en aansluiten tijdelijke slibverlading en tijdelijk geurfilter waterlijn |  | 2w | 2022-09-20 | 2022-10-03 | 46SS | 150d | 5d |  |
| 49 | 2.8.7.4 | Slopen slibverlading en geurfilters en overig voorbereiden grondwerk voor Terreinrioolput, E&I gebouw en 2e influentgoot |  | 2w | 2022-10-11 | 2022-10-24 | 48, 47 | 145d | 0d |  |
| 50 | 2.8.7.5 | Schroefpalen voor diverse objecten aanbrengen |  | 2w | 2022-10-25 | 2022-11-07 | 49 | 145d | 0d |  |

| ID | WBS | Task | Duration | Start | Finish | Predecessors | Total slack | Free slack |
| --- | --- | --- | --- | --- | --- | --- | --- | --- |
| 51 | 2.8.7.6 | **Funderingen** | 34d | 2022-11-01 | 2022-12-18 |  | 145d |  |
| 52 | 2.8.7.6.1 | Fundering E&I gebouw | 5d | 2022-11-01 | 2022-11-07 | 50FS-5d | 145d | 0d |
| 53 | 2.8.7.6.2 | Uitharden fundering E&I gebouw | 20ed | 2022-11-07 | 2022-11-27 | 52 | 805.88d | 1.88d |
| 54 | 2.8.7.6.3 | Overige funderingen | 15d | 2022-11-08 | 2022-11-28 | 52 | 145d | 0d |
| 55 | 2.8.7.6.4 | Uitharden funderingen | 20ed | 2022-11-28 | 2022-12-18 | 54 | 631.88d | 1.88d |
| 56 | 2.8.7.7 | **Geurfilters waterlijn** | 25d | 2022-12-19 | 2023-01-27 |  | 203d |  |
| 57 | 2.8.7.7.1 | Plaatsen en aansluiten nieuwe geurfilters waterlijn | 25d | 2022-12-19 | 2023-01-27 | 55, 17 | 203d | 58d |
| 58 | 2.8.7.8 | **E&I gebouw** | 64d | 2022-10-11 | 2023-01-13 |  | 206d |  |
| 59 | 2.8.7.8.1 | Trekputten en mantelbuizen aanbrengen | 4w | 2022-10-11 | 2022-11-07 | 47 | 342d |  |
| 60 | 2.8.7.8.2 | E&I gebouw bouwen | 20d | 2022-11-28 | 2022-12-23 | 53 | 172d | 0d |
| 61 | 2.8.7.8.3 | Verdelers en kasten plaatsen en aansluiten op trafo | 2w | 2023-01-02 | 2023-01-13 | 60, 17 | 172d | 0d |
| 62 | 2.8.7.9 | **Slibontwatering** | 45d | 2023-01-09 | 2023-03-10 |  | 178d |  |
| 63 | 2.8.7.9.1 | Plaatsen tijdelijke slibonwateringsvoorziening | 5d | 2023-01-09 | 2023-01-16 | 64SF | 298d |  |
| 64 | 2.8.7.9.2 | Verwijderen slibontwateringsmachine | 5d | 2023-01-16 | 2023-01-20 | 52FF, 61 | 173d | 0d |
| 65 | 2.8.7.9.3 | Plaatsen Nieuwe slibontwateringsmachine | 5d | 2023-01-16 | 2023-01-20 | 64FS-5d, 14 | 173d | 0d |
| 66 | 2.8.7.9.4 | Plaatsen slibsilo | 5d | 2023-01-16 | 2023-01-20 | 65SS, 14, 55 | 293d |  |
| 67 | 2.8.7.9.5 | Afmonteren ontwateringsinstallaties en slibsilo W+E | 4w | 2023-01-23 | 2023-02-17 | 65 | 173d | 0d |
| 68 | 2.8.7.9.6 | SAT Slibontwatering en storingsvrije periode | 2w | 2023-02-20 | 2023-03-03 | 67 | 173d | 0d |
| 69 | 2.8.7.9.7 | Verwijderen tijdelijke slibontwatering en verlading | 1w | 2023-03-06 | 2023-03-10 | 68 | 173d | 28d |
| 70 | 2.8.7.10 | **Blowers** | 46d | 2023-01-09 | 2023-03-13 |  | 172d |  |
| 71 | 2.8.7.10.1 | Plaatsen aansluiten en testen nieuwe blower 4 | 3w | 2023-01-09 | 2023-01-27 | 61FS-5d, 14 | 172d | 0d |
| 72 | 2.8.7.10.2 | Vervangen blower 1 | 2w | 2023-01-31 | 2023-02-13 | 14, 71FS+1d | 172d | 0d |
| 73 | 2.8.7.10.3 | Vervangen blower 2 | 2w | 2023-02-14 | 2023-02-27 | 72 | 172d | 0d |
| 74 | 2.8.7.10.4 | Vervangen blower 3 | 2w | 2023-02-28 | 2023-03-13 | 73 | 172d | 27d |

| ID | WBS | Task | Duration | Start | Finish | Predecessors | Total slack | Free slack |
| --- | --- | --- | --- | --- | --- | --- | --- | --- |
| 75 | 2.8.7.11 | **Roostergoed** | 83d | 2022-12-19 | 2023-04-19 |  | 145d |  |
| 76 | 2.8.7.11.1 | Bouwen 2e influentgoot en roostergoedgoot | 9w | 2022-12-19 | 2023-02-24 | 50, 55 | 145d | 0d |
| 77 | 2.8.7.11.2 | Opstellen en aansluiten tijdelijke roostergoedinstallatie | 2w | 2023-02-27 | 2023-03-10 | 61, 76 | 145d | 0d |
| 78 | 2.8.7.11.3 | Schuiven, Roostergoedinstallaties aanbrengen, zandvang reinigen en repareren | 20d | 2023-03-13 | 2023-04-07 | 77, 61, 14 | 145d | 0d |
| 79 | 2.8.7.11.4 | Testen en IBS | 5d | 2023-04-10 | 2023-04-14 | 78 | 145d | 0d |
| 80 | 2.8.7.11.5 | Verwijderen tijdelijk roostergoedinstallatie | 3d | 2023-04-17 | 2023-04-19 | 79 | 145d | 0d |
| 81 | 2.8.7.12 | **Terreinriolering en bedrijfswater** | 15d | 2022-11-29 | 2022-12-19 |  | 227d |  |
| 82 | 2.8.7.12.1 | Plaatsen prefab terreinrioolput | 5d | 2022-11-29 | 2022-12-05 | 50FS+10d, 17 | 227d | 0d |
| 83 | 2.8.7.12.2 | Inrichten en aansluiten terreinriolering en afvoer | 10d | 2022-12-06 | 2022-12-19 | 82 | 227d | 82d |
| 84 | 2.8.7.13 | **Retourslibgemaal** | 35d | 2023-01-09 | 2023-02-24 |  | 188d |  |
| 85 | 2.8.7.13.1 | Plaatsen TPI voor retourslib | 5d | 2023-01-09 | 2023-01-13 | 86SS-5d | 298d |  |
| 86 | 2.8.7.13.2 | Slopen installaties | 1w | 2023-01-16 | 2023-01-20 | 61 | 183d | 0d |
| 87 | 2.8.7.13.3 | Betonreparaties | 1w | 2023-01-23 | 2023-01-27 | 86 | 183d | 0d |
| 88 | 2.8.7.13.4 | Monteren nieuwe gemalen | 2w | 2023-01-30 | 2023-02-10 | 87, 17 | 183d | 0d |
| 89 | 2.8.7.13.5 | Indraaien en SAT | 5d | 2023-02-13 | 2023-02-17 | 88 | 183d | 0d |
| 90 | 2.8.7.13.6 | Verwijderen tijdelijke retourslibinstallatie | 5d | 2023-02-20 | 2023-02-24 | 89 | 183d | 38d |
| 91 | 2.9 | Afronden en ISAT | 4w | 2023-04-20 | 2023-05-17 | 42, 90, 83, 80, 74, 69, 57 | 145d | 0d |
| 92 | 2.10 | **AWTG's** | 216d | 2022-04-26 | 2023-03-21 |  | 191d |  |
| 93 | 2.10.1 | **Werkzaamheden AWTG Alphen West** | 151d | 2022-04-26 | 2022-12-13 |  | 191d |  |
| 94 | 2.10.1.1 | Engineering C/W/E onderdelen lange levertijd | 40d | 2022-04-26 | 2022-06-20 | 11 | 191d | 0d |
| 95 | 2.10.1.2 | Bestellen C/W/E onderdelen lange levertijd | 80d | 2022-06-07 | 2022-10-17 | 94FS-10d | 357d | 0d |
| 96 | 2.10.1.3 | Werkplan TPI | 5d | 2022-05-10 | 2022-05-16 | 94SS+10d | 191d | 0d |
| 97 | 2.10.1.4 | Engineering gereed | 1d | 2022-06-21 | 2022-06-21 | 94 | 426d |  |
| 98 | 2.10.1.5 | Levertijd pompen + FAT | 80d | 2022-06-07 | 2022-10-17 | 95SS | 357d |  |
| 99 | 2.10.1.6 | Levertijd TPI | 70d | 2022-05-17 | 2022-09-12 | 96 | 191d | 0d |
| 100 | 2.10.1.7 | Levertijd schakelkast + FAT | 30d | 2022-06-07 | 2022-07-18 | 95SS | 407d |  |
| 101 | 2.10.1.8 | Plaatsen TPI | 5d | 2022-09-13 | 2022-09-19 | 99 | 191d | 0d |
| 102 | 2.10.1.9 | Proefdraaien TPI | 5d | 2022-09-20 | 2022-09-26 | 101 | 191d | 0d |
| 103 | 2.10.1.10 | Bedrijfsperiode TPI | 55d | 2022-09-27 | 2022-12-12 | 102 | 191d | 0d |
| 104 | 2.10.1.11 | Amoveren bestaande installaties C/W/E | 10d | 2022-09-27 | 2022-10-10 | 103SS | 256d | 0d |
| 105 | 2.10.1.12 | Civiele werkzaamheden | 10d | 2022-10-11 | 2022-10-24 | 104 | 271d | 15d |
| 106 | 2.10.1.13 | Werktuigbouwkundige werkzaamheden | 15d | 2022-10-11 | 2022-10-31 | 104 | 266d | 10d |
| 107 | 2.10.1.14 | Elektrotechnische werkzaamheden | 25d | 2022-10-11 | 2022-11-14 | 104 | 256d | 0d |
| 108 | 2.10.1.15 | Montage eind inspectie (WTB/ E) | 1d | 2022-11-15 | 2022-11-15 | 105, 106, 107 | 256d | 0d |
| 109 | 2.10.1.16 | I/O testen | 5d | 2022-11-16 | 2022-11-22 | 108 | 256d | 0d |
| 110 | 2.10.1.17 | PA Sotware implementeren | 1d | 2022-11-23 | 2022-11-23 | 109 | 256d | 0d |
| 111 | 2.10.1.18 | SAT capaciteitstest 1 | 2d | 2022-11-24 | 2022-11-25 | 110 | 256d | 0d |
| 112 | 2.10.1.19 | Inbedrijfname AWTG | 1d | 2022-11-28 | 2022-11-28 | 111 | 256d | 0d |
| 113 | 2.10.1.20 | 14 dagen test (storingsvrije periode) | 14ed | 2022-11-28 | 2022-12-12 | 112 | 1180.88d | 1.88d |
| 114 | 2.10.1.21 | Restpunten/ Terreinafwerking | 5d | 2022-11-29 | 2022-12-05 | 112 | 256d | 0d |
| 115 | 2.10.1.22 | Opleverdossier | 80d | 2022-07-19 | 2022-11-29 | 94SS, 114SF | 261d | 10d |
| 116 | 2.10.1.23 | Vervroegde ingebruikneming AWTG | 1d | 2022-12-13 | 2022-12-13 | 113, 114, 115 | 251d | 106d |

| ID | WBS | Task | Duration | Start | Finish | Predecessors | Total slack | Free slack |
| --- | --- | --- | --- | --- | --- | --- | --- | --- |
| 117 | 2.10.2 | **Werkzaamheden AWTG Alphen Kerk en Zanen** | 201d | 2022-05-17 | 2023-03-21 |  | 241d |  |
| 118 | 2.10.2.1 | Engineering C/W/E onderdelen lange levertijd | 40d | 2022-05-17 | 2022-07-11 | 94SS+15d | 241d | 0d |
| 119 | 2.10.2.2 | Bestellen C/W/E onderdelen lange levertijd | 80d | 2022-06-28 | 2022-11-07 | 118FS-10d | 251d | 0d |
| 120 | 2.10.2.3 | Werkplan TPI | 5d | 2022-05-31 | 2022-06-06 | 118SS+10d | 241d | 0d |
| 121 | 2.10.2.4 | Engineering gereed | 1d | 2022-07-12 | 2022-07-12 | 118 | 411d |  |
| 122 | 2.10.2.5 | Levertijd pompen + FAT | 80d | 2022-06-28 | 2022-11-07 | 119SS | 342d |  |
| 123 | 2.10.2.6 | Levertijd TPI | 70d | 2022-06-07 | 2022-10-03 | 120 | 241d | 50d |
| 124 | 2.10.2.7 | Levertijd schakelkast + FAT | 30d | 2022-06-28 | 2022-08-29 | 119SS | 392d |  |
| 125 | 2.10.2.8 | Plaatsen TPI | 5d | 2022-12-13 | 2022-12-19 | 123, 103 | 191d | 0d |
| 126 | 2.10.2.9 | Proefdraaien TPI | 5d | 2022-12-20 | 2023-01-02 | 125 | 191d | 0d |
| 127 | 2.10.2.10 | Bedrijfsperiode TPI | 55d | 2023-01-03 | 2023-03-20 | 126 | 191d | 0d |
| 128 | 2.10.2.11 | Amoveren bestaande installaties C/W/E | 10d | 2023-01-03 | 2023-01-16 | 127SS | 191d | 0d |
| 129 | 2.10.2.12 | Civiele werkzaamheden | 25d | 2023-01-17 | 2023-02-20 | 128 | 191d | 0d |
| 130 | 2.10.2.13 | Werktuigbouwkundige werkzaamheden | 10d | 2023-01-17 | 2023-01-30 | 128 | 206d | 15d |
| 131 | 2.10.2.14 | Elektrotechnische werkzaamheden | 25d | 2023-01-17 | 2023-02-20 | 128 | 191d | 0d |
| 132 | 2.10.2.15 | Montage eind inspectie (WTB/ E) | 1d | 2023-02-21 | 2023-02-21 | 129, 130, 131, 142 | 191d | 0d |
| 133 | 2.10.2.16 | I/O testen | 5d | 2023-02-22 | 2023-02-28 | 132 | 191d | 0d |
| 134 | 2.10.2.17 | PA Sotware implementeren | 1d | 2023-03-01 | 2023-03-01 | 133 | 191d | 0d |
| 135 | 2.10.2.18 | SAT capaciteitstest 1 | 2d | 2023-03-02 | 2023-03-03 | 134 | 191d | 0d |
| 136 | 2.10.2.19 | Inbedrijfname AWTG | 1d | 2023-03-06 | 2023-03-06 | 135 | 191d | 0d |
| 137 | 2.10.2.20 | 14 dagen test (storingsvrije periode) | 14ed | 2023-03-06 | 2023-03-20 | 136 | 886.88d | 1.88d |
| 138 | 2.10.2.21 | Restpunten/ Terreinafwerking | 5d | 2023-03-07 | 2023-03-13 | 136 | 191d | 0d |
| 139 | 2.10.2.22 | Opleverdossier | 80d | 2022-11-08 | 2023-03-07 | 118SS, 138SF | 196d | 10d |
| 140 | 2.10.2.23 | Vervroegde ingebruikneming AWTG | 1d | 2023-03-21 | 2023-03-21 | 137, 138, 139 | 186d | 41d |

| ID | WBS | Task | Type | Duration | Start | Finish | Predecessors | Total slack | Free slack | Constraint |
| --- | --- | --- | --- | --- | --- | --- | --- | --- | --- | --- |
| 141 | 2.10.3 | **Werkzaamheden AWTG Hazerwoude Rijndijk** |  | 16d | 2022-10-31 | 2022-11-22 |  | 256.5d |  |  |
| 142 | 2.10.3.1 | Civiele werkzaamheden |  | 10d | 2022-11-08 | 2022-11-21 | 119 | 251d | 60d |  |
| 143 | 2.10.3.2 | Monteren en aansluiten meting |  | 2d | 2022-11-08 | 2022-11-09 | 119 | 331.5d | 0d |  |
| 144 | 2.10.3.3 | Montage eind inspectie (WTB/ E) |  | 1d | 2022-11-10 | 2022-11-10 | 143 | 331.5d | 0d |  |
| 145 | 2.10.3.4 | I/O testen |  | 0.5d | 2022-11-11 | 2022-11-11 | 144 | 331.5d | 0d |  |
| 146 | 2.10.3.5 | PA Sotware implementeren |  | 0.5d | 2022-11-11 | 2022-11-11 | 145 | 331.5d | 0d |  |
| 147 | 2.10.3.6 | SAT capaciteitstest 1 |  | 0.5d | 2022-11-14 | 2022-11-14 | 146 | 331.5d | 0d |  |
| 148 | 2.10.3.7 | Inbedrijfname AWTG | milestone | 0d | 2022-11-14 | 2022-11-14 | 147 | 331.5d | 0d |  |
| 149 | 2.10.3.8 | Restpunten/ Terreinafwerking |  | 5d | 2022-11-14 | 2022-11-21 | 148 | 331.5d | 0d |  |
| 150 | 2.10.3.9 | Opleverdossier |  | 10d | 2022-10-31 | 2022-11-14 | 149SF | 336.5d | 5d |  |
| 151 | 2.10.3.10 | Vervroegde ingebruikneming AWTG (MIJLPAAL) |  | 1d | 2022-11-21 | 2022-11-22 | 149, 150 | 331.5d |  |  |
| 152 | 2.11 | Oplevering (MIJLPAAL) | milestone | 0d | 2023-05-17 | 2023-05-17 | 91, 140, 116 | 145d | 0d |  |
| 153 | 2.12 | Restpunten en nazorg |  | 13w | 2023-05-18 | 2023-09-06 | 152 | 145d |  |  |
| 155 | 2.13 | **UITVOERINGSFASE ZK ALPHEN NOORD** |  | 467d | 2022-04-25 | 2024-04-10 |  | 0d |  |  |
| 156 | 2.13.1 | Datum van aanvang | milestone | 0d | 2022-04-25 | 2022-04-25 | 9FS+5d | 0d |  |  |
| 157 | 2.13.2 | Engineering aannemer |  | 80d | 2022-04-26 | 2022-09-05 | 156 | 0d |  |  |
| 158 | 2.13.3 | Engineering aannemer gereed [UM] | milestone | 0d | 2022-09-05 | 2022-09-05 | 157 | 387d |  |  |
| 159 | 2.13.4 | Bestellen/reserveren long lead items (Ontwateringsmachine, silo, blowers) |  | 6mo | 2022-06-21 | 2023-01-02 | 157FS-40d | 30d | 20d |  |
| 160 | 2.13.5 | Bestellen en inkoop |  | 80d | 2022-08-30 | 2022-12-19 | 157FS-5d | 128d |  |  |
| 161 | 2.13.6 | **Werkzaamheden awzi Alphen Noord** |  | 355d | 2022-06-30 | 2024-01-10 |  | 23d |  |  |
| 162 | 2.13.6.1 | **Fase 0** |  | 0d | 2022-06-30 | 2022-06-30 |  | 420d |  |  |
| 163 | 2.13.6.1.1 | Aansluiting aangepast (Liander) | milestone | 0d | 2022-06-30 | 2022-06-30 |  | 395d |  | start no earlier than 2022-06-30 |
| 164 | 2.13.6.2 | **Fase 1** |  | 25d | 2022-08-23 | 2022-09-26 |  | 0d |  |  |
| 165 | 2.13.6.2.1 | Mobilisatie |  | 2w | 2022-08-23 | 2022-09-05 | 157FS-10d | 0d |  |  |
| 166 | 2.13.6.2.2 | Verplaatsen Lavafilter + slopen + paalfundering aanbrengen (boren) |  | 4w | 2022-08-23 | 2022-09-19 | 165SS | 0d |  |  |
| 167 | 2.13.6.2.3 | Installeren bemaling |  | 10d | 2022-09-13 | 2022-09-26 | 166FS-5d | 0d |  |  |

| ID | WBS | Task | Type | Duration | Start | Finish | Predecessors | Total slack | Free slack |
| --- | --- | --- | --- | --- | --- | --- | --- | --- | --- |
| 168 | 2.13.6.3 | **Fase 2** |  | 170d | 2022-09-27 | 2023-05-29 |  | 0d |  |
| 169 | 2.13.6.3.1 | Ontgraven bouwkuip (talud 1:2) voor OW+SE+SS+ER |  | 5d | 2022-09-27 | 2022-10-03 | 166, 167 | 0d |  |
| 170 | 2.13.6.3.2 | **ONTVANGWERK + SLIBONTWATERING +SILO+ E-RUIMTES + LEIDINGEN** |  | 165d | 2022-10-04 | 2023-05-29 |  | 0d |  |
| 171 | 2.13.6.3.2.1 | vloer + kespen leidingen |  | 4w | 2022-10-04 | 2022-10-31 | 169 | 0d |  |
| 172 | 2.13.6.3.2.2 | wanden |  | 5w | 2022-11-01 | 2022-12-05 | 171 | 0d |  |
| 173 | 2.13.6.3.2.3 | dek + uitharden |  | 4w | 2022-12-06 | 2023-01-09 | 172 | 0d |  |
| 174 | 2.13.6.3.2.4 | Aanbrengen staalconstructies en leuningen |  | 2w | 2022-12-20 | 2023-01-09 | 173FF | 302d |  |
| 175 | 2.13.6.3.2.5 | bouwkundige afwerking gebouw (rekening houden met stempels) |  | 7w | 2023-01-10 | 2023-02-27 | 173 | 0d |  |
| 176 | 2.13.6.3.2.6 | watertesten putten + leidingen |  | 10d | 2023-01-10 | 2023-01-23 | 172, 173 | 5d | 0d |
| 177 | 2.13.6.3.2.7 | Spanningsbemaling uit | milestone | 0d | 2023-01-23 | 2023-01-23 | 176 | 292d |  |
| 178 | 2.13.6.3.2.8 | aanvullen |  | 1w | 2023-01-24 | 2023-01-30 | 176 | 5d | 0d |
| 179 | 2.13.6.3.2.9 | container- en lavafilteropstelplaats |  | 3w | 2023-01-31 | 2023-02-20 | 178 | 5d |  |
| 180 | 2.13.6.3.2.10 | Silo + trap +bordessen plaatsen |  | 2w | 2023-01-31 | 2023-02-13 | 159, 178 | 10d |  |
| 181 | 2.13.6.3.2.11 | geschikt voor W installatie | milestone | 0w | 2023-02-27 | 2023-02-27 | 175, 178, 179, 180 | 0d |  |
| 182 | 2.13.6.3.2.12 | Aanbrengen W en E installatie |  | 13w | 2023-02-28 | 2023-05-29 | 159, 181 | 0d |  |
| 183 | 2.13.6.3.2.13 | Aansluiten gebruikers bestaande installatie + gebruikers nieuwbouw op nieuwe MCC/MRK, zuivering blijft operationeel |  | 13w | 2023-02-28 | 2023-05-29 | 182FF | 0d |  |
| 184 | 2.13.6.3.2.14 | Aanpassen Terreinriolering en bedrijfswater in BG2 |  | 2w | 2023-05-16 | 2023-05-29 | 183FF | 127d |  |
| 185 | 2.13.6.4 | **Fase 3** |  | 35d | 2023-05-16 | 2023-07-03 |  | 0d |  |
| 186 | 2.13.6.4.1 | Plaatsen en aansluiten TPI naar BT1 en BT2 vanaf nieuw roostergoedgebouw; [TPI] |  | 2w | 2023-05-16 | 2023-05-29 | 187SS | 0d |  |
| 187 | 2.13.6.4.2 | Plaatsen en aansluiten tijdelijk leidingwerk voor leeg pompen VBT |  | 2w | 2023-05-16 | 2023-05-29 | 160SS+8w, 165, 183FF | 0d |  |
| 188 | 2.13.6.4.3 | Buitengebruik stellen spoelen en leeg pompen voorbezinktank |  | 1w | 2023-05-30 | 2023-06-05 | 186 | 0d |  |
| 189 | 2.13.6.4.4 | Plaatsen en aansluiten TPI voor slibretourgemalen [TPI], afdichten verzamelput voor slibretourgemalen |  | 1w | 2023-05-30 | 2023-06-05 | 188FF | 0d |  |
| 190 | 2.13.6.4.5 | Aanpassen selector (incl. reinigen) |  | 4w | 2023-06-06 | 2023-07-03 | 186, 188 | 0d |  |
| 191 | 2.13.6.4.6 | Vervangen slibretourgemalen |  | 4w | 2023-06-06 | 2023-07-03 | 189 | 0d |  |

| ID | WBS | Task | Type | Duration | Start | Finish | Predecessors | Total slack | Free slack | Constraint |
| --- | --- | --- | --- | --- | --- | --- | --- | --- | --- | --- |
| 192 | 2.13.6.5 | **Fase 4** |  | 45d | 2023-06-27 | 2023-09-18 |  | 5d |  |  |
| 193 | 2.13.6.5.1 | Aanpassen beluchtingstank 1 |  | 8w | 2023-07-04 | 2023-09-18 | 160FS+7d, 188, 190, 191 | 0d |  |  |
| 194 | 2.13.6.5.2 | Beluchtingstank 1 gereed voor bouwvakantie 2023 [UM] | milestone | 0d | 2023-07-28 | 2023-07-28 |  | 134d |  | start no earlier than 2023-07-28 |
| 195 | 2.13.6.5.3 | Plaatsen tijdelijke beluchtingsinstallatie [TBI] |  | 1w | 2023-06-27 | 2023-07-03 | 182, 193SS-5d | 62d | 0d |  |
| 196 | 2.13.6.5.4 | Vervangen blowerinstallatie en definitief aansluiten BT's |  | 4w | 2023-07-04 | 2023-08-21 | 195 | 62d |  |  |
| 197 | 2.13.6.6 | **Fase 5** |  | 40d | 2023-09-21 | 2023-11-15 |  | 0d |  |  |
| 198 | 2.13.6.6.1 | Aanpassen beluchtingstank 2 |  | 8w | 2023-09-21 | 2023-11-15 | 193FS+2d | 0d |  |  |
| 199 | 2.13.6.7 | **Fase 6** |  | 10d | 2023-11-16 | 2023-11-29 |  | 0d |  |  |
| 200 | 2.13.6.7.1 | Aanpassen Nabezinktank 2 |  | 2w | 2023-11-16 | 2023-11-29 | 196, 198 | 0d |  |  |
| 201 | 2.13.6.8 | **Fase 7** |  | 120d | 2023-06-15 | 2023-12-20 |  | 70d |  |  |
| 202 | 2.13.6.8.1 | Aanpassen Nabezinktank 1 |  | 2w | 2023-11-30 | 2023-12-13 | 200 | 0d |  |  |
| 203 | 2.13.6.8.2 | Capaciteitstest [TPI] |  | 1w | 2023-12-14 | 2023-12-20 | 184, 202 | 0d |  |  |
| 204 | 2.13.6.8.3 | AWZI volledig functioneel | milestone | 0d | 2023-12-20 | 2023-12-20 | 203 | 0d |  |  |
| 205 | 2.13.6.8.4 | Opleverdossier |  | 120d | 2023-06-15 | 2023-12-20 | 204FF | 70d |  |  |
| 206 | 2.13.6.9 | **Fase 8** |  | 132d | 2023-06-06 | 2024-01-10 |  | 0d |  |  |
| 207 | 2.13.6.9.1 | Slopen VBT + RGB + BG1 +SC (incl. bemaling) |  | 16w | 2023-06-06 | 2023-10-16 | 188 | 27d | 0d |  |
| 208 | 2.13.6.9.2 | Afwerken terrein, inclusief biodiversiteitsmaatregelen; |  | 4w | 2023-10-17 | 2023-11-13 | 207 | 27d |  |  |
| 209 | 2.13.6.9.3 | Demobilisatie. |  | 1w | 2023-12-21 | 2024-01-10 | 204, 208 | 0d |  |  |
| 210 | 2.13.7 | **Werkzaamheden AWTG Alphen Kennedylaan [TPI]** |  | 150d | 2022-04-26 | 2022-12-12 |  | 256d |  |  |
| 211 | 2.13.7.1 | Engineering C/W/E onderdelen lange levertijd |  | 40d | 2022-04-26 | 2022-06-20 | 156 | 256d | 0d |  |
| 212 | 2.13.7.2 | Bestellen C/W/E onderdelen lange levertijd |  | 80d | 2022-06-07 | 2022-10-17 | 211FS-10d | 357d | 0d |  |
| 213 | 2.13.7.3 | Werkplan TPI |  | 5d | 2022-05-10 | 2022-05-16 | 211SS+10d | 256d | 0d |  |
| 214 | 2.13.7.4 | Engineering gereed |  | 1d | 2022-06-21 | 2022-06-21 | 211 | 426d |  |  |
| 215 | 2.13.7.5 | Levertijd TPI |  | 70d | 2022-05-17 | 2022-09-12 | 213 | 256d | 0d |  |
| 216 | 2.13.7.6 | Levertijd schakelkast + FAT |  | 30d | 2022-06-07 | 2022-07-18 | 212SS | 407d |  |  |
| 217 | 2.13.7.7 | Plaatsen TPI |  | 5d | 2022-09-13 | 2022-09-19 | 215 | 256d | 0d |  |
| 218 | 2.13.7.8 | Proefdraaien TPI |  | 5d | 2022-09-20 | 2022-09-26 | 217 | 256d | 0d |  |
| 219 | 2.13.7.9 | Bedrijfsperiode TPI |  | 55d | 2022-09-27 | 2022-12-12 | 218 | 256d | 0d |  |
| 220 | 2.13.7.10 | Amoveren bestaande installaties C/W/E |  | 10d | 2022-09-27 | 2022-10-10 | 219SS | 256d | 0d |  |
| 221 | 2.13.7.11 | Civiele werkzaamheden |  | 15d | 2022-10-11 | 2022-10-31 | 220 | 266d | 10d |  |
| 222 | 2.13.7.12 | Werktuigbouwkundige werkzaamheden |  | 15d | 2022-10-11 | 2022-10-31 | 220 | 266d | 10d |  |
| 223 | 2.13.7.13 | Elektrotechnische werkzaamheden |  | 25d | 2022-10-11 | 2022-11-14 | 220 | 256d | 0d |  |
| 224 | 2.13.7.14 | Montage eind inspectie (WTB/ E) |  | 1d | 2022-11-15 | 2022-11-15 | 221, 222, 223 | 256d | 0d |  |
| 225 | 2.13.7.15 | I/O testen |  | 5d | 2022-11-16 | 2022-11-22 | 224 | 256d | 0d |  |
| 226 | 2.13.7.16 | PA Sotware implementeren |  | 1d | 2022-11-23 | 2022-11-23 | 225 | 256d | 0d |  |
| 227 | 2.13.7.17 | SAT capaciteitstest 1 |  | 2d | 2022-11-24 | 2022-11-25 | 226 | 256d | 0d |  |
| 228 | 2.13.7.18 | Inbedrijfname AWTG |  | 1d | 2022-11-28 | 2022-11-28 | 227 | 256d | 0d |  |
| 229 | 2.13.7.19 | 7 dagen test (storingsvrije periode) |  | 7ed | 2022-11-28 | 2022-12-05 | 228 | 1201.88d | 1.88d |  |
| 230 | 2.13.7.20 | Restpunten/ Terreinafwerking |  | 5d | 2022-11-29 | 2022-12-05 | 228 | 256d | 0d |  |
| 231 | 2.13.7.21 | Opleverdossier |  | 80d | 2022-07-19 | 2022-11-29 | 211SS, 230SF | 261d | 5d |  |
| 232 | 2.13.7.22 | Vervroegde ingebruikneming AWTG (MIJLPAAL) |  | 1d | 2022-12-06 | 2022-12-06 | 229, 230, 231 | 256d |  |  |
| 233 | 2.13.8 | Oplevering (MIJLPAAL) | milestone | 0d | 2024-01-10 | 2024-01-10 | 207, 209, 232 | 0d |  |  |
| 234 | 2.13.9 | Restpunten en nazorg |  | 13w | 2024-01-11 | 2024-04-10 | 233 | 0d |  |  |
